# ProjektovýPlán-TrénerMentálnychSchopností_2.0

Schedule from MS Project, 2011-02-14 to 2011-05-06.

## Calendars

- Standard: Mon-Fri 08:00-12:00, 13:00-17:00; Sat-Sun off.

## Resources

| Resource |
| --- |
| RS |
| OU |
| MB |
| GD |
| PB |
| AL |

## Schedule

| ID | WBS | Task | Type | Duration | Start | Finish | Predecessors | Total slack | Constraint | Resources | Work | Text1 |
| --- | --- | --- | --- | --- | --- | --- | --- | --- | --- | --- | --- | --- |
| 1 | 1 | **Projekt Tréner mentálnych schopností** |  | 60d? | 2011-02-14 | 2011-05-06 |  | 0d |  |  | 2528h |  |
| 2 | 1.1 | **Tímový projekt LS** |  | 60d? | 2011-02-14 | 2011-05-06 |  | 0d |  |  | 2528h | 1-12 |
| 3 | 1.1.1 | **Nadviazanie na predošlú prácu** |  | 5d? | 2011-02-14 | 2011-02-18 |  | 0d |  |  | 184h |  |
| 4 | 1.1.1.1 | Zhodnotenie stavu a výsledkov zo ZS |  | 1d | 2011-02-14 | 2011-02-14 |  | 0d | start no earlier than 2011-02-14 | RS; OU; MB | 24h |  |
| 5 | 1.1.1.2 | Dopracovanie zistených nedostatkov |  | 3d | 2011-02-15 | 2011-02-17 | 4 | 0d |  | RS; OU; MB; GD; PB; AL | 144h |  |
| 6 | 1.1.1.3 | Špecifikácia a dopracovanie plánu na LS |  | 1d? | 2011-02-18 | 2011-02-18 | 5 | 0d |  | RS; OU | 16h |  |
| 7 | 1.1.2 | **Príprava na ďalšiu prácu** |  | 5d | 2011-02-21 | 2011-02-25 |  | 0d |  |  | 144h |  |
| 8 | 1.1.2.1 | Aktualizácia dokumentácie |  | 4d | 2011-02-21 | 2011-02-24 | 6 | 0d |  | OU; RS; GD | 96h |  |
| 9 | 1.1.2.2 | Vypracovanie plánu integrácie a plánu overenia výsledku |  | 1d | 2011-02-25 | 2011-02-25 | 8 | 0d |  | RS; OU; MB; GD; PB; AL | 48h |  |
| 10 | 1.1.3 | **Práca v LS** |  | 50d | 2011-02-28 | 2011-05-06 |  | 0d |  |  | 2200h | 3-12 |
| 11 | 1.1.3.1 | Implementácia funkcionality a hier, testovanie |  | 5d | 2011-02-28 | 2011-03-04 | 9 | 0d |  | RS; OU; MB; GD; PB; AL | 240h |  |
| 12 | 1.1.3.2 | Implementácia funkcionality a hier, testovanie |  | 5d | 2011-03-07 | 2011-03-11 | 11 | 0d |  | RS; OU; MB; GD; PB; AL | 240h |  |
| 13 | 1.1.3.3 | Implementácia funkcionality a hier, testovanie |  | 5d | 2011-03-14 | 2011-03-18 | 12 | 0d |  | RS; OU; MB; GD; PB; AL | 240h |  |
| 14 | 1.1.3.4 | Implementácia funkcionality a hier, testovanie |  | 5d | 2011-03-21 | 2011-03-25 | 13 | 0d |  | RS; OU; MB; GD; PB; AL | 240h |  |
| 15 | 1.1.3.5 | Integrácia, overovanie |  | 5d | 2011-03-28 | 2011-04-01 | 14 | 0d |  | RS; OU; MB; GD; PB; AL | 240h |  |
| 16 | 1.1.3.6 | Integrácia, overovanie, dokumentovanie |  | 5d | 2011-04-04 | 2011-04-08 | 15 | 0d |  | RS; OU; MB; GD; PB; AL | 240h |  |
| 17 | 1.1.3.7 | Odovzdanie dokumentácie | milestone | 0d | 2011-04-11 | 2011-04-11 | 16 | 20d | start no earlier than 2011-04-11 | OU; RS |  |  |
| 18 | 1.1.3.8 | Integrácia, overovanie |  | 5d | 2011-04-11 | 2011-04-15 | 16 | 0d |  | RS; OU; MB; GD; PB; AL | 240h |  |
| 19 | 1.1.3.9 | Externé testovanie, údržba, kompletizácia dokumentácie |  | 5d | 2011-04-18 | 2011-04-22 | 18 | 0d |  | RS; OU; MB; GD; PB; AL | 240h | 10 |
| 20 | 1.1.3.10 | Externé testovanie, údržba, kompletizácia dokumentácie |  | 5d | 2011-04-25 | 2011-04-29 | 19 | 0d |  | RS; OU; MB; GD; PB; AL | 240h | 11 |
| 21 | 1.1.3.11 | Odovzdanie výsledku projektu |  | 5d | 2011-05-02 | 2011-05-06 | 20 | 0d |  | RS | 40h | 12 |
